# FirstLaunch

Schedule from MS Project, 2014-01-06 to 2015-02-13, status date 2013-10-01.

## Calendars

- Standard: Mon-Fri 08:00-12:00, 13:00-17:00; Sat-Sun off.

## Schedule

| ID | WBS | Task | Duration | Start | Finish | Predecessors | Total slack |
| --- | --- | --- | --- | --- | --- | --- | --- |
| 1 | 1 | **Programming and Planning** | 61d | 2014-01-06 | 2014-03-31 |  | 0d |
| 2 | 1.1 | PIF Submitted by Department or Administration | 1d | 2014-01-06 | 2014-01-06 |  | 0d |
| 3 | 1.2 | D&C Initial Meeting with Dept/PIF Completed | 10d | 2014-01-07 | 2014-01-20 | 2 | 0d |
| 4 | 1.3 | Establish Preliminary Project Budget & Schedule | 5d | 2014-01-21 | 2014-01-27 | 3 | 0d |
| 5 | 1.4 | Establish/Approval of Planning Funds | 30d | 2014-01-28 | 2014-03-10 | 4 | 0d |
| 6 | 1.5 | Programming | 10d | 2014-03-11 | 2014-03-24 | 5 | 0d |
| 7 | 1.6 | Architect Selection/Contract | 5d | 2014-03-25 | 2014-03-31 | 6 | 0d |
| 8 | 2 | **Design Documents** | 35d | 2014-04-01 | 2014-05-19 |  | 0d |
| 9 | 2.1 | Schematic Design Documents | 10d | 2014-04-01 | 2014-04-14 | 7 | 0d |
| 10 | 2.2 | Design Development Documents | 10d | 2014-04-15 | 2014-04-28 | 9 | 0d |
| 11 | 2.3 | Commissioning RFP | 10d | 2014-04-29 | 2014-05-12 | 10 | 199d |
| 12 | 2.4 | Construction Documents | 30d | 2014-04-08 | 2014-05-19 | 14FF | 0d |
| 13 | 2.5 | Permitting and Jurisdictional Reviews | 5d | 2014-04-22 | 2014-04-28 | 10FF | 209d |
| 14 | 3 | **WUSM Internal Coordination and Reviews** | 25d | 2014-04-15 | 2014-05-19 |  | 0d |
| 15 | 3.1 | **Design & Construction** | 15d | 2014-04-29 | 2014-05-19 |  | 0d |
| 16 | 3.1.1 | 50% Drawing Review | 3d | 2014-04-29 | 2014-05-01 | 10 | 12d |
| 17 | 3.1.2 | 90% Drawing Review - PM with Dept | 5d | 2014-05-13 | 2014-05-19 | 10SS+20d | 0d |
| 18 | 3.1.3 | 90% Drawing Review with Facilities | 5d | 2014-05-13 | 2014-05-19 | 10SS+20d | 0d |
| 19 | 3.2 | Facilities Engineering | 10d | 2014-04-29 | 2014-05-12 | 10 | 5d |
| 20 | 3.3 | TFC and IT | 15d | 2014-04-15 | 2014-05-05 | 9 | 10d |
| 21 | 3.4 | Environmental Health & Safety (EH&S) | 10d | 2014-04-15 | 2014-04-28 | 9 | 15d |
| 22 | 3.5 | Security | 5d | 2014-04-29 | 2014-05-05 | 10 | 10d |
| 23 | 3.6 | Transportation | 5d | 2014-04-29 | 2014-05-05 | 10 | 10d |
| 24 | 3.7 | Custodial Services | 10d | 2014-04-15 | 2014-04-28 | 9 | 15d |
| 25 | 3.8 | Signage | 10d | 2014-04-29 | 2014-05-12 | 10 | 5d |
| 26 | 3.9 | Audio Visual (A/V) | 5d | 2014-04-15 | 2014-04-21 | 9 | 20d |
| 27 | 3.10 | Keying | 10d | 2014-04-29 | 2014-05-12 | 10 | 5d |
| 28 | 3.11 | Furniture | 15d | 2014-04-29 | 2014-05-19 | 10 | 0d |

| ID | WBS | Task | Type | Duration | Start | Finish | Predecessors | Total slack | Free slack |
| --- | --- | --- | --- | --- | --- | --- | --- | --- | --- |
| 29 | 4 | **Bidding** |  | 30d | 2014-05-20 | 2014-06-30 |  | 0d |  |
| 30 | 4.1 | Develop Contractor List & Issue Invitation to Bid |  | 5d | 2014-05-20 | 2014-05-26 | 12 | 0d |  |
| 31 | 4.2 | Pre-Bid Project Review Meeting | milestone | 1d | 2014-05-27 | 2014-05-27 | 30 | 188d |  |
| 32 | 4.3 | Bids Time Frame/Bids Due/Bid Opening |  | 10d | 2014-05-27 | 2014-06-09 | 30 | 0d |  |
| 33 | 4.4 | Bid Evaluation/Bid Award/Notice to Proceed | milestone | 15d | 2014-06-10 | 2014-06-30 | 32 | 0d |  |
| 34 | 5 | **Procurement of Owner Furnished Items** |  | 90d | 2014-05-20 | 2014-09-22 |  | 61d |  |
| 35 | 5.1 | Furniture Procurement |  | 40d | 2014-05-20 | 2014-07-14 | 12 | 94d |  |
| 36 | 5.2 | Keying and Cores Procurement |  | 30d | 2014-05-20 | 2014-06-30 | 12 | 122d | 104d |
| 37 | 5.3 | Equipment Procurement |  | 60d | 2014-05-20 | 2014-08-11 | 12 | 84d | 74d |
| 38 | 5.4 | Signage Procurement |  | 30d | 2014-05-20 | 2014-06-30 | 12, 25 | 122d | 104d |
| 39 | 5.5 | A/V Procurement |  | 30d | 2014-05-20 | 2014-06-30 | 12 | 119d | 104d |
| 40 | 5.6 | Artwork Procurement |  | 90d | 2014-05-20 | 2014-09-22 | 12 | 61d | 44d |
| 41 | 5.7 | Procure Moving Bids |  | 10d | 2014-05-20 | 2014-06-02 | 12 | 184d |  |
| 42 | 6 | **Construction** |  | 104d | 2014-07-01 | 2014-11-21 |  | 0d |  |
| 43 | 6.1 | Pre-Construction Kick Off Meeting | milestone | 1d | 2014-07-01 | 2014-07-01 | 33 | 0d |  |
| 44 | 6.2 | Construction Time Frame |  | 100d | 2014-07-02 | 2014-11-18 | 43 | 0d |  |
| 45 | 6.3 | Systems Furniture Installation |  | 10d | 2014-11-05 | 2014-11-18 | 44FF | 2d |  |
| 46 | 6.4 | Commissioning |  | 20d | 2014-10-22 | 2014-11-18 | 44FF | 2d |  |
| 47 | 6.5 | Punch List Inspection |  | 2d | 2014-11-19 | 2014-11-20 | 44 | 0d |  |
| 48 | 6.6 | Substantial Completion | milestone | 1d | 2014-11-21 | 2014-11-21 | 47, 45, 46 | 0d |  |
| 49 | 7 | **Occupancy** |  | 30d | 2014-11-24 | 2015-01-02 |  | 0d |  |
| 50 | 7.1 | Misc. Furniture Installation |  | 15d | 2014-11-24 | 2014-12-12 | 48, 35 | 0d |  |
| 51 | 7.2 | Equipment Installation |  | 10d | 2014-11-24 | 2014-12-05 | 48, 37 | 10d |  |
| 52 | 7.3 | Installation of Cores |  | 2d | 2014-11-24 | 2014-11-25 | 48, 36 | 18d |  |
| 53 | 7.4 | Signage Installation |  | 2d | 2014-11-24 | 2014-11-25 | 48, 38 | 18d |  |
| 54 | 7.5 | A/V Installation |  | 5d | 2014-11-24 | 2014-11-28 | 48, 39 | 15d |  |
| 55 | 7.6 | Artwork Installation |  | 3d | 2014-11-24 | 2014-11-26 | 40, 48 | 17d |  |
| 56 | 7.7 | Activation of Phone Lines |  | 5d | 2014-12-15 | 2014-12-19 | 50, 48 | 0d |  |
| 57 | 7.8 | Department Occupancy/Relocation |  | 10d | 2014-12-22 | 2015-01-02 | 56, 50, 51, 52, 53, 54, 55 | 0d |  |

| ID | WBS | Task | Type | Duration | Start | Finish | Predecessors | Total slack |
| --- | --- | --- | --- | --- | --- | --- | --- | --- |
| 58 | 8 | **Post Occupancy** |  | 60d | 2014-11-24 | 2015-02-13 |  | 0d |
| 59 | 8.1 | Project Financial Close Out |  | 30d | 2015-01-05 | 2015-02-13 | 49 | 0d |
| 60 | 8.2 | Assemble and Turn Over O&M's and Record Drawings |  | 30d | 2014-11-24 | 2015-01-02 | 42 | 30d |
| 61 | 9 | Project Completion | milestone | 0d | 2015-02-13 | 2015-02-13 | 59, 60 | 0d |
